# EDR-DampingRings

Schedule from MS Project, 2007-06-01 to 2010-04-29.
Daresbury Laboratory

## Calendars

- Standard: Mon-Fri 08:00-12:00, 13:00-17:00; Sat-Sun off.

## Resources

| Resource |
| --- |
| Vacuum Design Engineer 1 |
| Lattice Designer 1 |
| Impedance Calculator 1 |
| Instability Modeller 1 |
| Acceptance Analyst 1 |
| Vacuum System Engineer 1 |
| Magnet Design Engineer 1 |
| Magnet Design Engineer 2 |
| Vacuum Design Engineer 2 |
| Power System Engineer 1 |
| Instability Modeller 2 |
| Wiggler Design Engineer 1 |
| RF System Design Engineer 1 |
| Feedback System Designer 1 |
| Fast Kicker Researcher 1 |
| Optics Correction Analyst 1 |
| Civil Engineer 1 |
| Beam Dump Designer 1 |
| Fast Kicker Designer 1 |
| Control System Designer 1 |
| Cryogenics System Designer 1 |

## Schedule

| ID | WBS | Task | Type | Duration | Start | Finish | Predecessors | Total slack | Free slack | Resources | Work |
| --- | --- | --- | --- | --- | --- | --- | --- | --- | --- | --- | --- |
| 1 | 1 | **Optics and beam dynamics** |  | 760d | 2007-06-01 | 2010-04-29 |  | 0d |  |  | 10400h |
| 2 | 1.1 | **Lattice design** |  | 600d | 2007-06-01 | 2009-09-17 |  | 20d |  |  | 5440h |
| 3 | 1.1.1 | Set lattice specifications | milestone | 0d | 2007-06-01 | 2007-06-01 |  | 20d | 0d |  |  |
| 4 | 1.1.2 | Develop damping rings lattice designs |  | 8mo | 2007-06-01 | 2008-01-10 | 3 | 20d | 0d | Lattice Designer 1 | 1280h |
| 5 | 1.1.3 | Select and "freeze" baseline lattice design | milestone | 0d | 2008-01-10 | 2008-01-10 | 4, 18, 69, 56, 51, 53, 43 | 20d | 0d |  |  |
| 6 | 1.1.4 | Develop baseline design of injection/extraction lines |  | 3mo | 2008-01-11 | 2008-04-03 | 4 | 540d | 0d | Lattice Designer 1 | 480h |
| 7 | 1.1.5 | "Freeze" baseline design of injection/extraction lines | milestone | 0d | 2008-04-03 | 2008-04-03 | 6 | 540d |  |  |  |
| 8 | 1.1.6 | Develop baseline design of abort line |  | 3mo | 2008-01-11 | 2008-04-03 | 137, 4 | 40d | 0d | Lattice Designer 1 | 480h |
| 9 | 1.1.7 | "Freeze" baseline design of abort line | milestone | 0d | 2008-04-03 | 2008-04-03 | 8 | 60d | 0d |  |  |
| 10 | 1.1.8 | Explore optimisations and operational flexibility |  | 15mo | 2008-04-04 | 2009-05-28 | 8 | 40d | 0d | Lattice Designer 1 | 2400h |
| 11 | 1.1.9 | Make necessary changes to lattice design |  | 3mo | 2009-05-29 | 2009-08-20 | 23, 61, 10 | 40d | 0d | Lattice Designer 1 | 480h |
| 12 | 1.1.10 | Make necessary changes to injection/extraction lines |  | 1mo | 2009-08-21 | 2009-09-17 | 11 | 160d |  | Lattice Designer 1 | 160h |
| 13 | 1.1.11 | Make necessary changes to abort line |  | 1mo | 2009-08-21 | 2009-09-17 | 11 | 40d | 0d | Lattice Designer 1 | 160h |
| 14 | 1.1.12 | Lattice designs finalised and documented | milestone | 0d | 2009-09-17 | 2009-09-17 | 13 | 40d | 0d |  |  |
| 15 | 1.2 | **Impedance and impedance-driven instabilities** |  | 760d | 2007-06-01 | 2010-04-29 |  | 0d |  |  | 2080h |
| 16 | 1.2.1 | Construct impedance model from scaled component designs |  | 4mo | 2007-06-01 | 2007-09-20 |  | 0d |  |  |  |
| 17 | 1.2.2 | Model instabilities using preliminary impedance model |  | 3mo | 2007-09-21 | 2007-12-13 | 16 | 0d |  |  |  |
| 18 | 1.2.3 | Make instability estimates based on preliminary impedance model | milestone | 0d | 2007-12-13 | 2007-12-13 | 17 | 40d | 20d |  |  |
| 19 | 1.2.4 | Refine and improve impedance models and instability calculations |  | 12mo | 2007-12-14 | 2008-11-13 | 17 | 0d |  |  |  |
| 20 | 1.2.5 | Construct impedance model using real technical designs |  | 4mo | 2008-11-14 | 2009-03-05 | 88, 117, 19, 126 | 0d |  | Impedance Calculator 1 | 640h |
| 21 | 1.2.6 | Understand impact of single-bunch and coupled-bunch instabilities, and injection/extraction transients |  | 3mo | 2009-03-06 | 2009-05-28 | 20, 5 | 0d |  | Instability Modeller 1 | 480h |
| 22 | 1.2.7 | Estimates of coupled-bunch instability growth rates | milestone | 0d | 2009-05-28 | 2009-05-28 | 21 | 60d | 0d |  |  |
| 23 | 1.2.8 | Specify improvements to lattice and vacuum designs | milestone | 0d | 2009-05-28 | 2009-05-28 | 21 | 0d |  |  |  |
| 24 | 1.2.9 | Refine and improve impedance models and instability calculations |  | 6mo | 2009-05-29 | 2009-11-12 | 21 | 0d |  |  |  |
| 25 | 1.2.10 | Finalise impedance model |  | 3mo | 2009-11-13 | 2010-02-04 | 91, 24 | 0d |  | Impedance Calculator 1 | 480h |
| 26 | 1.2.11 | Characterise instabilities using detailed impedance model |  | 3mo | 2010-02-05 | 2010-04-29 | 25, 14 | 0d |  | Instability Modeller 1 | 480h |
| 27 | 1.2.12 | Predict instability characteristics and thresholds | milestone | 0d | 2010-04-29 | 2010-04-29 | 26 | 0d |  |  |  |

| ID | WBS | Task | Type | Duration | Start | Finish | Predecessors | Total slack | Free slack | Constraint |
| --- | --- | --- | --- | --- | --- | --- | --- | --- | --- | --- |
| 28 | 1.3 | **Electron cloud** |  | 648d | 2007-06-01 | 2009-11-24 |  | 20d |  |  |
| 29 | 1.3.1 | Evaluate electron cloud mitigation techniques |  | 15mo | 2007-06-01 | 2008-07-24 |  | 20d | 0d |  |
| 30 | 1.3.2 | Specify baseline ecloud mitigation techniques | milestone | 0d | 2008-07-24 | 2008-07-24 | 29 | 20d | 0d |  |
| 31 | 1.3.3 | Start construction of test dipole chamber |  | 15mo | 2007-06-01 | 2008-07-24 |  | 160d | 0d |  |
| 32 | 1.3.4 | Finalise construction of test dipole chamber |  | 2mo | 2008-07-25 | 2008-09-18 | 31, 29 | 160d | 0d |  |
| 33 | 1.3.5 | Test ecloud mitigation techniques in dipole chamber |  | 6mo | 2008-09-19 | 2009-03-05 | 32 | 160d | 0d |  |
| 34 | 1.3.6 | Start construction of test wiggler chamber |  | 15mo | 2007-06-01 | 2008-07-24 |  | 160d | 0d |  |
| 35 | 1.3.7 | Finalise construction of test wiggler chamber |  | 2mo | 2008-07-25 | 2008-09-18 | 34, 29 | 160d | 0d |  |
| 36 | 1.3.8 | Test ecloud mitigation techniques in wiggler chamber |  | 6mo | 2008-09-19 | 2009-03-05 | 35 | 160d | 0d |  |
| 37 | 1.3.9 | Model ecloud build-up with baseline mitigation techniques |  | 1mo | 2009-03-06 | 2009-04-02 | 33, 36 | 160d | 48d |  |
| 38 | 1.3.10 | Benchmark electron cloud instability codes |  | 9mo | 2008-10-01 | 2009-06-09 |  | 112d | 0d | start no earlier than 2008-10-01 |
| 39 | 1.3.11 | Model electron cloud instabilities |  | 6mo | 2009-06-10 | 2009-11-24 | 38, 37 | 112d | 0d |  |
| 40 | 1.3.12 | Validate design for ecloud mitigation, and predict ecloud instability safety margins | milestone | 0d | 2009-11-24 | 2009-11-24 | 39 | 112d |  |  |
| 41 | 1.4 | **Ion effects** |  | 360d | 2007-06-01 | 2008-10-16 |  | 20d |  |  |
| 42 | 1.4.1 | Use existing models to estimate ion effects under various fill/vacuum conditions |  | 7mo | 2007-06-01 | 2007-12-13 |  | 20d | 0d |  |
| 43 | 1.4.2 | Make initial specification of vacuum conditions to mitigate fast ion instability | milestone | 0d | 2007-12-13 | 2007-12-13 | 42 | 20d | 0d |  |
| 44 | 1.4.3 | Collect experimental data on fast ion instability |  | 12mo | 2007-06-01 | 2008-05-01 |  | 20d | 0d |  |
| 45 | 1.4.4 | Benchmark fast ion instability modelling codes |  | 3mo | 2008-05-02 | 2008-07-24 | 44 | 20d | 0d |  |
| 46 | 1.4.5 | Run simulations of fast ion instability for various vacuum and operational conditions |  | 3mo | 2008-07-25 | 2008-10-16 | 45 | 20d | 0d |  |
| 47 | 1.4.6 | Specify vacuum conditions and fast feedback systems performance to avoid effects from fast ion instability | milestone | 0d | 2008-10-16 | 2008-10-16 | 46 | 20d | 0d |  |
| 48 | 1.5 | **Other collective effects** |  | 600d | 2007-06-01 | 2009-09-17 |  | 60d |  |  |
| 49 | 1.5.1 | Placeholder for space-charge studies |  | 30mo | 2007-06-01 | 2009-09-17 |  | 160d |  |  |
| 50 | 1.5.2 | Initial estimates of intrabeam scattering |  | 6mo | 2007-06-01 | 2007-11-15 |  | 60d | 0d |  |
| 51 | 1.5.3 | Initial estimates of intrabeam scattering | milestone | 0d | 2007-11-15 | 2007-11-15 | 50 | 60d | 40d |  |
| 52 | 1.5.4 | initial estimates of Touschek lifetime |  | 6mo | 2007-06-01 | 2007-11-15 |  | 60d | 0d |  |
| 53 | 1.5.5 | Initial estimates of Touschek lifetime | milestone | 0d | 2007-11-15 | 2007-11-15 | 52 | 60d | 40d |  |

| ID | WBS | Task | Type | Duration | Start | Finish | Predecessors | Total slack | Free slack | Resources | Work |
| --- | --- | --- | --- | --- | --- | --- | --- | --- | --- | --- | --- |
| 54 | 1.6 | **Acceptance** |  | 700d | 2007-06-01 | 2010-02-04 |  | 40d |  |  | 960h |
| 55 | 1.6.1 | Make preliminary estimates of dynamic aperture |  | 7mo | 2007-06-01 | 2007-12-13 |  | 40d | 0d |  |  |
| 56 | 1.6.2 | Preliminary estimates of dynamic aperture | milestone | 0d | 2007-12-13 | 2007-12-13 | 55 | 40d | 20d |  |  |
| 57 | 1.6.3 | Specify magnet field quality | milestone | 0d | 2007-12-13 | 2007-12-13 | 55 | 40d | 0d | Acceptance Analyst 1 |  |
| 58 | 1.6.4 | Specify physical apertures | milestone | 0d | 2007-12-13 | 2007-12-13 | 55 | 40d | 20d |  |  |
| 59 | 1.6.5 | Explore dynamic aperture limitations and possible improvement techniques |  | 12mo | 2008-01-11 | 2008-12-11 | 55, 5 | 60d | 0d |  |  |
| 60 | 1.6.6 | Characterise acceptance using technical designs of magnets |  | 3mo | 2008-12-12 | 2009-03-05 | 107, 95, 59 | 60d | 0d | Acceptance Analyst 1 | 480h |
| 61 | 1.6.7 | Understand acceptance limitations using technical designs of magnets | milestone | 0d | 2009-03-05 | 2009-03-05 | 60 | 100d | 60d |  |  |
| 62 | 1.6.8 | Explore dynamic aperture limitations and possible improvement techniques |  | 9mo | 2009-03-06 | 2009-11-12 | 60 | 60d | 0d |  |  |
| 63 | 1.6.9 | Complete studies of acceptance |  | 3mo | 2009-11-13 | 2010-02-04 | 14, 62 | 60d | 0d | Acceptance Analyst 1 | 480h |
| 64 | 1.6.10 | Confirm acceptance margin on injected beam | milestone | 0d | 2010-02-04 | 2010-02-04 | 63 | 60d |  |  |  |
| 65 | 1.7 | **Orbit, optics and coupling correction** |  | 660d | 2007-06-01 | 2009-12-10 |  | 40d |  |  | 1920h |
| 66 | 1.7.1 | Experimental studies of orbit and coupling correction |  | 24mo | 2007-06-01 | 2009-04-02 |  | 100d | 0d |  |  |
| 67 | 1.7.2 | Demonstrate 2 pm vertical emittance | milestone | 0d | 2009-04-02 | 2009-04-02 | 66 | 140d | 0d |  |  |
| 68 | 1.7.3 | Make initial estimates of alignment sensitivities in baseline lattice |  | 7mo | 2007-06-01 | 2007-12-13 |  | 40d | 0d |  |  |
| 69 | 1.7.4 | Initial estimates of alignment sensitivities | milestone | 0d | 2007-12-13 | 2007-12-13 | 68 | 40d | 20d |  |  |
| 70 | 1.7.5 | Specify and evaluate possible orbit and coupling correction schemes |  | 9mo | 2008-01-11 | 2008-09-18 | 5, 68 | 60d | 20d | Optics Correction Analyst 1 | 1440h |
| 71 | 1.7.6 | Evaluate impact of ground vibration, temperature variations and long-term ground motion |  | 6mo | 2008-10-17 | 2009-04-02 | 101, 70 | 40d | 0d |  |  |
| 72 | 1.7.7 | Initial estimates of impact of ground vibration, temperature variations and long-term ground motion | milestone | 0d | 2009-04-02 | 2009-04-02 | 71 | 40d | 0d |  |  |
| 73 | 1.7.8 | Optimise orbit and coupling correction scheme |  | 6mo | 2009-04-03 | 2009-09-17 | 71, 66 | 100d | 0d |  |  |
| 74 | 1.7.9 | Finalise orbit and coupling correction scheme |  | 3mo | 2009-09-18 | 2009-12-10 | 14, 73, 104 | 100d | 0d | Optics Correction Analyst 1 | 480h |
| 75 | 1.7.10 | Correction systems documented and costed | milestone | 0d | 2009-12-10 | 2009-12-10 | 74 | 100d |  |  |  |
| 76 | 1.8 | **Preservation of polarisation** |  | 560d | 2008-01-11 | 2010-03-04 |  | 40d |  |  |  |
| 77 | 1.8.1 | Preliminary evaluation of depolarisation rates |  | 16mo | 2008-01-11 | 2009-04-02 | 5 | 40d | 0d |  |  |
| 78 | 1.8.2 | Evaluate depolarisation rates including realistic alignment and tuning model |  | 12mo | 2009-04-03 | 2010-03-04 | 72, 77 | 40d | 0d |  |  |
| 79 | 1.8.3 | Report on preservation of polarisation | milestone | 0d | 2010-03-04 | 2010-03-04 | 78 | 40d |  |  |  |

| ID | WBS | Task | Type | Duration | Start | Finish | Predecessors | Total slack | Free slack | Resources | Work |
| --- | --- | --- | --- | --- | --- | --- | --- | --- | --- | --- | --- |
| 80 | 2 | **Technical subsystems** |  | 720d | 2007-06-01 | 2010-03-04 |  | 20d |  |  | 19840h |
| 81 | 2.1 | **Vacuum system** |  | 640d | 2007-06-01 | 2009-11-12 |  | 0d |  |  | 2240h |
| 82 | 2.1.1 | Preliminary vacuum system specifications |  | 1mo | 2007-06-01 | 2007-06-28 |  | 20d | 0d |  |  |
| 83 | 2.1.2 | Set baseline specifications for vacuum system (subject to ecloud studies) | milestone | 0d | 2007-06-28 | 2007-06-28 | 82 | 160d | 120d |  |  |
| 84 | 2.1.3 | Prepare initial technical designs of vacuum system components |  | 6mo | 2007-06-29 | 2007-12-13 | 82 | 20d | 0d |  |  |
| 85 | 2.1.4 | Review vacuum system specifications |  | 1mo | 2007-12-14 | 2008-01-10 | 84, 43 | 20d | 0d |  |  |
| 86 | 2.1.5 | Develop initial technical designs of vacuum system components |  | 7mo | 2008-01-11 | 2008-07-24 | 5, 58, 85 | 20d | 0d | Vacuum Design Engineer 1; Vacuum Design Engineer 2 | 2240h |
| 87 | 2.1.6 | Finalise technical designs of vacuum system components |  | 3mo | 2008-07-25 | 2008-10-16 | 86, 30 | 20d | 0d |  |  |
| 88 | 2.1.7 | Technical designs of vacuum system components | milestone | 0d | 2008-10-16 | 2008-10-16 | 87 | 20d |  |  |  |
| 89 | 2.1.8 | Optimise vacuum system for cost and technical performance |  | 7mo | 2008-10-17 | 2009-04-30 | 87, 47 | 20d |  |  |  |
| 90 | 2.1.9 | Make essential modifications to technical designs of vacuum system components |  | 6mo | 2009-05-29 | 2009-11-12 | 89, 23 | 0d |  |  |  |
| 91 | 2.1.10 | Vacuum system technical design finalised, documented and costed | milestone | 0d | 2009-11-12 | 2009-11-12 | 90 | 0d |  |  |  |
| 92 | 2.2 | **Magnets and supports** |  | 720d | 2007-06-01 | 2010-03-04 |  | 40d |  |  | 6880h |
| 93 | 2.2.1 | Specify magnets |  | 1mo | 2007-12-14 | 2008-01-10 | 57, 83 | 40d | 0d | Magnet Design Engineer 1 | 160h |
| 94 | 2.2.2 | Develop technical designs for main magnets |  | 12mo | 2008-01-11 | 2008-12-11 | 93 | 40d | 0d | Magnet Design Engineer 1; Magnet Design Engineer 2 | 3840h |
| 95 | 2.2.3 | Technical designs for main magnets | milestone | 0d | 2008-12-11 | 2008-12-11 | 94 | 60d | 0d |  |  |
| 96 | 2.2.4 | Optimise magnet designs for cost and performance |  | 10mo | 2008-12-12 | 2009-09-17 | 94 | 40d | 0d |  |  |
| 97 | 2.2.5 | Finalise designs of main magnets |  | 6mo | 2009-09-18 | 2010-03-04 | 14, 96 | 40d | 0d | Magnet Design Engineer 1; Magnet Design Engineer 2 | 1920h |
| 98 | 2.2.6 | Magnet designs documented and costed | milestone | 0d | 2010-03-04 | 2010-03-04 | 97 | 40d |  |  |  |
| 99 | 2.2.7 | Develop technical designs for magnet supports |  | 6mo | 2008-01-11 | 2008-06-26 | 93, 5 | 40d | 0d |  |  |
| 100 | 2.2.8 | Model magnet supports response to vibration and long-term stability |  | 4mo | 2008-06-27 | 2008-10-16 | 99 | 40d | 0d |  |  |
| 101 | 2.2.9 | Characterisation of magnet supports response to vibration and long-term stability | milestone | 0d | 2008-10-16 | 2008-10-16 | 100 | 40d | 0d |  |  |
| 102 | 2.2.10 | Optimisation of design of magnet supports |  | 4mo | 2008-12-12 | 2009-04-02 | 100, 94 | 140d | 0d |  |  |
| 103 | 2.2.11 | Finalise design of magnet supports |  | 4mo | 2009-04-03 | 2009-07-23 | 72, 102, 67 | 140d | 0d |  |  |
| 104 | 2.2.12 | Magnet supports documented and costed | milestone | 0d | 2009-07-23 | 2009-07-23 | 103 | 140d | 40d |  |  |

| ID | WBS | Task | Type | Duration | Start | Finish | Predecessors | Total slack | Free slack | Constraint | Resources | Work |
| --- | --- | --- | --- | --- | --- | --- | --- | --- | --- | --- | --- | --- |
| 105 | 2.2.13 | **Wiggler** |  | 120d | 2007-06-01 | 2007-11-15 |  | 340d |  |  |  | 960h |
| 106 | 2.2.13.1 | Develop technical design for wigglers |  | 6mo | 2007-06-01 | 2007-11-15 |  | 340d | 0d |  | Wiggler Design Engineer 1 | 960h |
| 107 | 2.2.13.2 | Wiggler design documented and costed | milestone | 0d | 2007-11-15 | 2007-11-15 | 106 | 340d | 280d |  |  |  |
| 108 | 2.3 | **Power systems** |  | 240d | 2008-12-12 | 2009-11-12 |  | 60d |  |  |  | 1920h |
| 109 | 2.3.1 | Specify magnet power supplies, power distribution and cooling system |  | 3mo | 2008-12-12 | 2009-03-05 | 95 | 60d | 0d |  | Power System Engineer 1 | 480h |
| 110 | 2.3.2 | Develop designs for power distribution and cooling systems |  | 9mo | 2009-03-06 | 2009-11-12 | 109 | 60d | 0d |  | Power System Engineer 1 | 1440h |
| 111 | 2.3.3 | Power systems documented and costed | milestone | 0d | 2009-11-12 | 2009-11-12 | 110 | 60d | 0d |  |  |  |
| 112 | 2.4 | **650 MHz RF system** |  | 540d | 2007-06-01 | 2009-06-25 |  | 60d |  |  |  | 3040h |
| 113 | 2.4.1 | Initial specifications for RF system |  | 3mo | 2007-06-01 | 2007-08-23 |  | 60d | 0d |  |  |  |
| 114 | 2.4.2 | Preliminary technical design of RF system |  | 4mo | 2007-08-24 | 2007-12-13 | 113 | 60d | 20d |  |  |  |
| 115 | 2.4.3 | Develop technical designs for RF cavities |  | 9mo | 2008-01-11 | 2008-09-18 | 114, 5 | 40d | 0d |  | RF System Design Engineer 1 | 1440h |
| 116 | 2.4.4 | Develop technical specifications/designs for modulators, klystrons, waveguide, couplers etc. |  | 9mo | 2008-01-11 | 2008-09-18 | 114, 5 | 40d | 0d |  |  |  |
| 117 | 2.4.5 | Technical design of RF components | milestone | 0d | 2008-09-18 | 2008-09-18 | 115, 116 | 40d |  |  |  |  |
| 118 | 2.4.6 | Finalise RF system technical designs |  | 10mo | 2008-09-19 | 2009-06-25 | 116 | 100d | 0d |  | RF System Design Engineer 1 | 1600h |
| 119 | 2.4.7 | Develop technical design for low-level RF |  | 6mo | 2008-09-19 | 2009-03-05 | 115, 116 | 180d | 80d | start no earlier than 2008-01-01 |  |  |
| 120 | 2.4.8 | RF system documentation and costing | milestone | 0d | 2009-06-25 | 2009-06-25 | 119, 118 | 100d | 0d |  |  |  |
| 121 | 2.5 | **Injection and extraction systems** |  | 600d | 2007-06-01 | 2009-09-17 |  | 140d |  |  |  | 1920h |
| 122 | 2.5.1 | Install single-bunch extraction system in ATF |  | 9mo | 2007-06-01 | 2008-02-07 |  | 580d | 0d |  |  |  |
| 123 | 2.5.2 | Demonstrate single-bunch extraction from ATF | milestone | 0d | 2008-02-07 | 2008-02-07 | 122 | 580d |  |  |  |  |
| 124 | 2.5.3 | Develop fast high-power pulser meeting damping ring specifications |  | 24mo | 2007-06-01 | 2009-04-02 |  | 160d | 0d |  |  |  |
| 125 | 2.5.4 | Develop technical design for kicker striplines |  | 12mo | 2007-06-01 | 2008-05-01 |  | 140d | 0d |  | Fast Kicker Researcher 1 | 1920h |
| 126 | 2.5.5 | Technical design for kicker striplines | milestone | 0d | 2008-05-01 | 2008-05-01 | 125 | 140d |  |  |  |  |
| 127 | 2.5.6 | Fabricate striplines for beam tests |  | 12mo | 2008-05-02 | 2009-04-02 | 125 | 160d | 0d |  |  |  |
| 128 | 2.5.7 | Install and test fast injection/extraction kicker system |  | 6mo | 2009-04-03 | 2009-09-17 | 124, 127 | 160d | 0d |  |  |  |
| 129 | 2.5.8 | Demonstrate injection/extraction kickers with damping ring specifications | milestone | 0d | 2009-09-17 | 2009-09-17 | 128 | 160d |  |  |  |  |

| ID | WBS | Task | Type | Duration | Start | Finish | Predecessors | Total slack | Free slack | Resources | Work |
| --- | --- | --- | --- | --- | --- | --- | --- | --- | --- | --- | --- |
| 130 | 2.6 | **Fast feedback systems** |  | 180d | 2009-05-29 | 2010-02-04 |  | 60d |  |  | 1440h |
| 131 | 2.6.1 | Develop technical design for longitudinal fast feedback system |  | 9mo | 2009-05-29 | 2010-02-04 | 5, 22, 117 | 60d | 0d | Feedback System Designer 1 | 1440h |
| 132 | 2.6.2 | Longitudinal fast feedback systems documented and costed | milestone | 0d | 2010-02-04 | 2010-02-04 | 131 | 60d |  |  |  |
| 133 | 2.6.3 | Develop technical design for transverse fast feedback system |  | 9mo | 2009-05-29 | 2010-02-04 | 5, 22, 117, 47 | 60d | 0d |  |  |
| 134 | 2.6.4 | Transverse fast feedback systems documented and costed | milestone | 0d | 2010-02-04 | 2010-02-04 | 133 | 60d |  |  |  |
| 135 | 2.7 | **Abort systems hardware** |  | 340d | 2007-06-01 | 2008-09-18 |  | 80d |  |  | 2400h |
| 136 | 2.7.1 | Develop technical design for abort dump |  | 6mo | 2007-06-01 | 2007-11-15 |  | 80d | 0d | Beam Dump Designer 1 | 960h |
| 137 | 2.7.2 | Technical design for abort dumpt | milestone | 0d | 2007-11-15 | 2007-11-15 | 136 | 80d | 40d |  |  |
| 138 | 2.7.3 | Develop technical designs for abort kickers |  | 9mo | 2008-01-11 | 2008-09-18 | 5 | 420d | 0d | Fast Kicker Designer 1 | 1440h |
| 139 | 2.7.4 | Abort systems documented and costed | milestone | 0d | 2008-09-18 | 2008-09-18 | 138 | 420d |  |  |  |
| 140 | 2.8 | **Instrumentation and diagnostics** |  | 720d | 2007-06-01 | 2010-03-04 |  | 40d |  |  |  |
| 141 | 2.8.1 | Instrumentation and diagnostics placeholder |  | 36mo | 2007-06-01 | 2010-03-04 |  | 40d |  |  |  |
| 142 | 2.9 | **Systems integration and availability studies** |  | 720d | 2007-06-01 | 2010-03-04 |  | 40d |  |  |  |
| 143 | 2.9.1 | Systems integration tasks placeholder |  | 36mo | 2007-06-01 | 2010-03-04 |  | 40d |  |  |  |
| 144 | 2.9.2 | Systems availability tasks placeholder |  | 36mo | 2007-06-01 | 2010-03-04 |  | 40d |  |  |  |
| 145 | 3 | **Global systems: integration into the organisational structure uncertain. Mostly placeholders** |  | 720d | 2007-06-01 | 2010-03-04 |  | 40d |  |  | 4320h |
| 146 | 3.1 | **Conventional facilities** |  | 480d | 2008-04-04 | 2010-02-04 |  | 60d |  |  | 2400h |
| 147 | 3.1.1 | Design excavations (tunnels and caverns) |  | 12mo | 2008-04-04 | 2009-03-05 | 9 | 60d | 0d | Civil Engineer 1 | 1920h |
| 148 | 3.1.2 | Design air conditioning/temperature stabilisation systems |  | 9mo | 2009-03-06 | 2009-11-12 | 147 | 60d | 0d |  |  |
| 149 | 3.1.3 | Finalise conventional facilities designs |  | 3mo | 2009-11-13 | 2010-02-04 | 111, 148 | 60d | 0d | Civil Engineer 1 | 480h |
| 150 | 3.1.4 | Conventional facilities documented and costed | milestone | 0d | 2010-02-04 | 2010-02-04 | 149 | 60d |  |  |  |
| 151 | 3.2 | **Control systems** |  | 120d | 2007-06-01 | 2007-11-15 |  | 640d |  |  | 960h |
| 152 | 3.2.1 | Specify control systems |  | 6mo | 2007-06-01 | 2007-11-15 |  | 640d | 0d | Control System Designer 1 | 960h |
| 153 | 3.2.2 | Control systems documented and costed | milestone | 0d | 2007-11-15 | 2007-11-15 | 152 | 640d |  |  |  |

| ID | WBS | Task | Type | Duration | Start | Finish | Predecessors | Total slack | Free slack | Resources | Work |
| --- | --- | --- | --- | --- | --- | --- | --- | --- | --- | --- | --- |
| 154 | 3.3 | **Cryogenics systems** |  | 120d | 2009-06-26 | 2009-12-10 |  | 100d |  |  | 960h |
| 155 | 3.3.1 | Specify cryogenics systems |  | 6mo | 2009-06-26 | 2009-12-10 | 120 | 100d | 0d | Cryogenics System Designer 1 | 960h |
| 156 | 3.3.2 | Cryogenics systems documented and costed | milestone | 0d | 2009-12-10 | 2009-12-10 | 155 | 100d |  |  |  |
| 157 | 3.4 | **Survey and alignment** |  | 720d | 2007-06-01 | 2010-03-04 |  | 40d |  |  |  |
| 158 | 3.4.1 | Survey and alignment placeholder |  | 36mo | 2007-06-01 | 2010-03-04 |  | 40d |  |  |  |
| 159 | 3.5 | **Installation and commissioning plan** |  | 720d | 2007-06-01 | 2010-03-04 |  | 40d |  |  |  |
| 160 | 3.5.1 | Installation plan placeholder |  | 36mo | 2007-06-01 | 2010-03-04 |  | 40d |  |  |  |
| 161 | 3.5.2 | Commisioning plan placeholder |  | 36mo | 2007-06-01 | 2010-03-04 |  | 40d |  |  |  |
| 162 | 4 | **Test facilities: placeholders for tasks specific to test facility development** |  | 720d | 2007-06-01 | 2010-03-04 |  | 40d |  |  |  |
| 163 | 4.1 | **ATF** |  | 720d | 2007-06-01 | 2010-03-04 |  | 40d |  |  |  |
| 164 | 4.1.1 | Experimental studies placeholder |  | 36mo | 2007-06-01 | 2010-03-04 |  | 40d |  |  |  |
| 165 | 4.2 | **CesrTA** |  | 720d | 2007-06-01 | 2010-03-04 |  | 40d |  |  |  |
| 166 | 4.2.1 | Experimental studies placeholder |  | 36mo | 2007-06-01 | 2010-03-04 |  | 40d |  |  |  |
| 167 | 4.3 | **KEKB** |  | 720d | 2007-06-01 | 2010-03-04 |  | 40d |  |  |  |
| 168 | 4.3.1 | Experimental studies placeholder |  | 36mo | 2007-06-01 | 2010-03-04 |  | 40d |  |  |  |
